# Reunion de accionistas universidad

Schedule from MS Project, 2025-05-06 to 2025-06-16, costs in $.
Informe anual

## Calendars

- RA2: Mon-Fri 08:00-16:00; Sat-Sun off. Exceptions (off unless hours are given): 2025-05-13 (No 4), 2025-05-24 (No 1), 2025-06-03 (No 2).

## Resources

| Resource | Group | Unit | Rate |
| --- | --- | --- | --- |
| Asistente | Oficina |  | 10 |
| Gerente | Directiva |  | 40.87 |
| Jefe funcional | Directiva |  | 21.63 |
| Comité | Oficina |  | 50 |
| Papel | Oficina | unidad | 5 |
| Viáticos | Oficina |  |  |
| Alquiler de Local | Oficina |  | 30 |

## Schedule

| ID | WBS | Task | Type | Duration | Start | Finish | Predecessors | Total slack | Free slack | Resources | Work | Cost |
| --- | --- | --- | --- | --- | --- | --- | --- | --- | --- | --- | --- | --- |
| 1 | 1 | **Planificacion preliminar** |  | 7d | 2025-05-06 | 2025-05-15 |  | 0d |  |  | 64h | 1,786.15 |
| 2 | 1.1 | Programar fecha de la conferencia |  | 2d | 2025-05-06 | 2025-05-07 |  | 0d |  | Jefe funcional | 16h | 346.15 |
| 3 | 1.2 | Reservar centro de conferencias |  | 3d | 2025-05-08 | 2025-05-12 | 2 | 0d |  | Asistente | 24h | 240 |
| 4 | 1.3 | Buscar conferenciante |  | 3d | 2025-05-12 | 2025-05-15 | 3FS-1d | 0d |  | Comité | 24h | 1,200 |
| 5 | 1.4 | Planificacion preliminar completa | milestone | 0d | 2025-05-15 | 2025-05-15 | 4 | 21d |  |  |  |  |
| 6 | 2 | **Carta de notificacion** |  | 8d | 2025-05-14 | 2025-05-23 |  | 0d |  |  | 72h | 2,030 |
| 7 | 2.1 | Ordenar lista de envio |  | 1d | 2025-05-14 | 2025-05-14 | 4SS+1d | 0d |  | Asistente | 8h | 80 |
| 8 | 2.2 | Preparar carta |  | 3d | 2025-05-14 | 2025-05-16 | 7SS | 0d |  | Comité | 24h | 1,200 |
| 9 | 2.3 | Revisar carta |  | 1d | 2025-05-19 | 2025-05-19 | 8 | 0d |  | Jefe funcional | 8h | 173.08 |
| 10 | 2.4 | Aprobar carta |  | 1d | 2025-05-20 | 2025-05-20 | 9 | 0d |  | Gerente | 8h | 326.92 |
| 11 | 2.5 | Imprimir carta |  | 2d | 2025-05-21 | 2025-05-22 | 10 | 1d | 0d | Asistente; Papel [2 unidad] | 16h | 170 |
| 12 | 2.6 | Enviar carta | milestone | 1d | 2025-05-23 | 2025-05-23 | 11 | 1d |  | Asistente | 8h | 80 |
| 13 | 3 | **Detalles de la reunion** |  | 11d | 2025-05-21 | 2025-06-05 |  | 0d |  |  | 96h | 3,799.23 |
| 14 | 3.1 | Preparar menu con empresa catering |  | 1w | 2025-05-21 | 2025-05-27 | 10 | 0d |  | Comité | 40h | 2,000 |
| 15 | 3.2 | Preparar sitio de reunion |  | 1d | 2025-05-27 | 2025-05-27 | 14FF, 12 | 0d |  | Comité | 8h | 400 |
| 16 | 3.3 | Preparar equipamiento necesario |  | 2d | 2025-05-28 | 2025-05-29 | 15 | 0d |  | Comité | 16h | 800 |
| 17 | 3.4 | Preparar programa |  | 3d | 2025-05-30 | 2025-06-04 | 16 | 0d |  | Jefe funcional | 24h | 519.23 |
| 18 | 3.5 | Imprimir programa |  | 1d | 2025-06-05 | 2025-06-05 | 17 | 0d |  | Asistente | 8h | 80 |
| 19 | 4 | Celebracion de la reunion |  | 2d | 2025-06-13 | 2025-06-16 | 13FS+5d | 0d |  | Viáticos [0.1%]; Alquiler de Local | 16h | 1,480 |
| 20 | 5 | Fin y Reporte de resultados | milestone | 0d | 2025-06-16 | 2025-06-16 | 19 | 0d |  |  |  |  |
